# EAP - IMPERMEABILIZAÇÃO DO EDIFÍCIO SEDE - DRF - FNS

Schedule from MS Project, 2026-10-01 to 2030-06-02, status date 2025-10-27.

## Calendars

- Padrão: Mon-Sun 08:00-12:00, 13:00-17:00.

## Schedule

| ID | WBS | Task | Type | Duration | Start | Finish | Predecessors | Total slack | Constraint | Text1 |
| --- | --- | --- | --- | --- | --- | --- | --- | --- | --- | --- |
| 1 | 1 | **CONTRATO - IMPERMEABILIZAÇÃO FNS** |  | 1340d | 2026-10-01 | 2030-06-02 |  | 0d |  |  |
| 2 | 1.1 | Ordem de Serviço | milestone | 0d | 2026-10-01 | 2026-10-01 |  | 0d | start no earlier than 2026-10-01 |  |
| 3 | 1.2 | Mobilização |  | 15d | 2026-10-01 | 2026-10-16 | 2 | 0d |  |  |
| 4 | 1.3 | **EAP - PROJETO DE IMPERMEABILIZAÇÃO DO EDIFÍCIO SEDE - DRF - FNS** |  | 365d | 2026-10-16 | 2027-10-16 |  | 0d |  |  |
| 5 | 1.3.1 | ART | milestone | 0d | 2026-10-16 | 2026-10-16 | 3 | 30d |  |  |
| 6 | 1.3.2 | PEB - Plano de Execução BIM |  | 30d | 2026-10-16 | 2026-11-15 | 3 | 0d | start no earlier than 2025-08-19 | Aumento de 15 dias |
| 7 | 1.3.3 | Recebimento do PEB |  | 5d | 2026-11-20 | 2026-11-25 | 6FS+5d, 5FS+5d | 35d |  |  |
| 8 | 1.3.4 | **Relatório de Análise Inicial e Diagnóstico** |  | 40d | 2026-11-20 | 2026-12-30 |  | 0d |  |  |
| 9 | 1.3.4.1 | Programa de Necessidades |  | 30d | 2026-11-20 | 2026-12-20 | 6FS+5d, 5FS+5d | 0d |  |  |
| 10 | 1.3.4.2 | Recebimento do Programa de Necessidades |  | 10d | 2026-12-20 | 2026-12-30 | 9 | 0d |  |  |
| 11 | 1.3.5 | **Projeto Básico** |  | 140d | 2026-12-30 | 2027-05-19 |  | 0d |  |  |
| 12 | 1.3.5.1 | Ordem de Serviço | milestone | 0d | 2026-12-30 | 2026-12-30 | 9FS+5d, 7, 10 | 0d |  |  |
| 13 | 1.3.5.2 | Projeto Arquitetônico da Cobertura e Fachadas |  | 75d | 2026-12-30 | 2027-03-15 | 12 | 0d |  | Inversão de ordens e predecessoras |
| 14 | 1.3.5.3 | Projeto de Paisagismo |  | 60d | 2027-01-19 | 2027-03-20 | 13FF+5d, 12 | 0d |  | Inversão de ordens e predecessoras |
| 15 | 1.3.5.4 | Projeto Luminotécnico |  | 60d | 2027-01-19 | 2027-03-20 | 13FF+5d, 12 | 0d |  | Inversão de ordens e predecessoras |
| 16 | 1.3.5.5 | Projeto de Impermeabilização da Cobertura |  | 60d | 2026-12-30 | 2027-02-28 | 12 | 20d |  |  |
| 17 | 1.3.5.6 | Projeto de Impermeabilização das Fachadas |  | 60d | 2026-12-30 | 2027-02-28 | 12 | 20d |  |  |
| 18 | 1.3.5.7 | Projeto de Adaptações Estruturais |  | 60d | 2026-12-30 | 2027-02-28 | 12 | 80d |  |  |
| 19 | 1.3.5.8 | Projeto Elétrico e SPDA |  | 60d | 2027-03-20 | 2027-05-19 | 13, 14, 15, 16, 17 | 0d |  |  |
| 20 | 1.3.6 | Aprovação do Projeto nos Órgãos Públicos |  | 60d | 2027-03-20 | 2027-05-19 | 13, 14, 15 | 25d |  | Inserção de Item |
| 21 | 1.3.7 | Recebimento PB |  | 15d | 2027-05-24 | 2027-06-08 | 19FS+5d, 16FS+5d, 13, 17FS+5d, 18FS+5d | 0d |  |  |
| 22 | 1.3.8 | **Projeto Executivo** |  | 125d | 2027-06-13 | 2027-10-16 |  | 0d |  |  |
| 23 | 1.3.8.1 | Ordem de Serviço | milestone | 0d | 2027-06-13 | 2027-06-13 | 21FS+5d | 0d |  |  |
| 24 | 1.3.8.2 | Projeto Arquitetônico da Cobertura e Fachadas |  | 60d | 2027-06-13 | 2027-08-12 | 23, 20 | 0d |  | Inversão de ordens e predecessoras |
| 25 | 1.3.8.3 | Projeto de Paisagismo |  | 60d | 2027-06-13 | 2027-08-12 | 23, 24FF | 0d |  | Inversão de ordens e predecessoras |
| 26 | 1.3.8.4 | Projeto Luminotécnico |  | 60d | 2027-06-13 | 2027-08-12 | 23, 24FF | 0d |  | Inversão de ordens e predecessoras |
| 27 | 1.3.8.5 | Projeto de Impermeabilização da Cobertura |  | 60d | 2027-06-13 | 2027-08-12 | 23 | 0d |  |  |
| 28 | 1.3.8.6 | Projeto de Impermeabilização das Fachadas |  | 60d | 2027-06-13 | 2027-08-12 | 23 | 0d |  |  |
| 29 | 1.3.8.7 | Projeto Elétrico e SPDA |  | 60d | 2027-06-13 | 2027-08-12 | 23 | 0d |  |  |
| 30 | 1.3.8.8 | Projeto de Adaptações Estruturais |  | 30d | 2027-06-13 | 2027-07-13 | 23 | 30d |  |  |
| 31 | 1.3.8.9 | Plano de Gerenciamento de Resíduos da Construção Civil |  | 30d | 2027-06-13 | 2027-07-13 | 23 | 30d |  |  |
| 32 | 1.3.8.10 | Orçamento Definitivo e Detalhado |  | 60d | 2027-08-17 | 2027-10-16 | 29FS+5d, 28FS+5d, 27FS+5d, 25FS+5d, 26FS+5d, 24FS+5d, 30FS+5d, 31FS+5d | 0d |  |  |
| 33 | 1.3.8.11 | Cronograma de Obra Definitivo e Detalhado |  | 60d | 2027-08-17 | 2027-10-16 | 29FS+5d, 28FS+5d, 27FS+5d, 25FS+5d, 26FS+5d, 24FS+5d, 30FS+5d, 31FS+5d | 0d |  |  |
| 34 | 1.4 | Recebimento do PE |  | 30d | 2027-10-16 | 2027-11-15 | 33, 32 | 0d |  |  |

| ID | WBS | Task | Type | Duration | Start | Finish | Predecessors | Total slack | Free slack | Text1 |
| --- | --- | --- | --- | --- | --- | --- | --- | --- | --- | --- |
| 35 | 1.5 | **EAP - OBRA DE IMPERMEABILIZAÇÃO DO EDIFÍCIO SEDE - DRF - FNS** |  | 720d | 2027-11-15 | 2029-11-04 |  | 0d |  |  |
| 36 | 1.5.1 | Ordem de Serviço | milestone | 0d | 2027-11-15 | 2027-11-15 | 34 | 0d |  |  |
| 37 | 1.5.2 | ART | milestone | 0d | 2027-11-15 | 2027-11-15 | 36 | 0d |  |  |
| 38 | 1.5.3 | Serviços Administrativos |  | 720d | 2027-11-15 | 2029-11-04 | 36, 37SS | 0d |  |  |
| 39 | 1.5.4 | **Serviços Operacionais** |  | 720d | 2027-11-15 | 2029-11-04 |  | 0d |  |  |
| 40 | 1.5.4.1 | Serviços Preliminares |  | 8d | 2027-11-15 | 2027-11-23 | 36 | 0d |  |  |
| 41 | 1.5.4.2 | Locação e aquisição de materiais e equipamentos para proteção e apoio para execução dos serviços |  | 720d | 2027-11-15 | 2029-11-04 | 36 | 0d |  |  |
| 42 | 1.5.4.3 | **Recuperação dos Sistemas de Impermeabilização** |  | 662d | 2027-11-23 | 2029-09-15 |  | 0d |  |  |
| 43 | 1.5.4.3.1 | **Bloco 1** |  | 107d | 2027-11-23 | 2028-03-09 |  | 0d |  |  |
| 44 | 1.5.4.3.1.1 | Ordem de Serviço Etapa | milestone | 0d | 2027-11-23 | 2027-11-23 | 40 | 0d |  |  |
| 45 | 1.5.4.3.1.2 | **Impermeabilização da Cobertura** |  | 57d | 2027-11-23 | 2028-01-19 |  | 0d |  |  |
| 46 | 1.5.4.3.1.2.1 | Demolições e Retiradas |  | 11d | 2027-11-23 | 2027-12-04 | 44 | 0d |  |  |
| 47 | 1.5.4.3.1.2.2 | Serviços preparatórios |  | 11d | 2027-11-29 | 2027-12-10 | 46FS-5d | 0d |  |  |
| 48 | 1.5.4.3.1.2.3 | Aplicação de Sistema de Impermeabilização |  | 40d | 2027-12-10 | 2028-01-19 | 47 | 0d |  |  |
| 49 | 1.5.4.3.1.3 | **Impermeabilização das Fachadas** |  | 52d | 2027-11-23 | 2028-01-14 |  | 5d |  |  |
| 50 | 1.5.4.3.1.3.1 | Demolições e Lavagem |  | 12d | 2027-11-23 | 2027-12-05 | 44 | 5d | 0d |  |
| 51 | 1.5.4.3.1.3.2 | Aplicação de Novo Revestimento Externo |  | 40d | 2027-12-05 | 2028-01-14 | 50 | 5d |  |  |
| 52 | 1.5.4.3.1.4 | Recuperação das pinturas internas |  | 45d | 2028-01-19 | 2028-03-04 | 51, 48 | 0d |  | Aumento de 15 dias |
| 53 | 1.5.4.3.1.5 | Recebimento Etapa | milestone | 0d | 2028-03-09 | 2028-03-09 | 52FS+5d | 0d |  |  |
| 54 | 1.5.4.3.2 | **Bloco 2** |  | 107d | 2028-03-09 | 2028-06-24 |  | 0d |  |  |
| 55 | 1.5.4.3.2.1 | Ordem de Serviço Etapa | milestone | 0d | 2028-03-09 | 2028-03-09 | 53 | 0d |  |  |
| 56 | 1.5.4.3.2.2 | **Impermeabilização da Cobertura** |  | 57d | 2028-03-09 | 2028-05-05 |  | 0d |  |  |
| 57 | 1.5.4.3.2.2.1 | Demolições e Retiradas |  | 11d | 2028-03-09 | 2028-03-20 | 55 | 0d |  |  |
| 58 | 1.5.4.3.2.2.2 | Serviços preparatórios |  | 11d | 2028-03-15 | 2028-03-26 | 57FS-5d | 0d |  |  |
| 59 | 1.5.4.3.2.2.3 | Aplicação de Sistema de Impermeabilização |  | 40d | 2028-03-26 | 2028-05-05 | 58 | 0d |  |  |

| ID | WBS | Task | Type | Duration | Start | Finish | Predecessors | Total slack | Free slack | Text1 |
| --- | --- | --- | --- | --- | --- | --- | --- | --- | --- | --- |
| 60 | 1.5.4.3.2.3 | **Impermeabilização das Fachadas** |  | 52d | 2028-03-09 | 2028-04-30 |  | 5d |  |  |
| 61 | 1.5.4.3.2.3.1 | Demolições e Lavagem |  | 12d | 2028-03-09 | 2028-03-21 | 55 | 5d | 0d |  |
| 62 | 1.5.4.3.2.3.2 | Aplicação de Novo Revestimento Externo |  | 40d | 2028-03-21 | 2028-04-30 | 61 | 5d |  |  |
| 63 | 1.5.4.3.2.4 | Recuperação das pinturas internas |  | 45d | 2028-05-05 | 2028-06-19 | 62, 59 | 0d |  | Aumento de 15 dias |
| 64 | 1.5.4.3.2.5 | Recebimento Etapa | milestone | 0d | 2028-06-24 | 2028-06-24 | 63FS+5d, 59 | 0d |  |  |
| 65 | 1.5.4.3.3 | **Bloco 3** |  | 107d | 2028-06-24 | 2028-10-09 |  | 0d |  |  |
| 66 | 1.5.4.3.3.1 | Ordem de Serviço Etapa | milestone | 0d | 2028-06-24 | 2028-06-24 | 64 | 0d |  |  |
| 67 | 1.5.4.3.3.2 | **Impermeabilização da Cobertura** |  | 57d | 2028-06-24 | 2028-08-20 |  | 0d |  |  |
| 68 | 1.5.4.3.3.2.1 | Demolições e Retiradas |  | 11d | 2028-06-24 | 2028-07-05 | 66 | 0d |  |  |
| 69 | 1.5.4.3.3.2.2 | Serviços preparatórios |  | 11d | 2028-06-30 | 2028-07-11 | 68FS-5d | 0d |  |  |
| 70 | 1.5.4.3.3.2.3 | Aplicação de Sistema de Impermeabilização |  | 40d | 2028-07-11 | 2028-08-20 | 69 | 0d |  |  |
| 71 | 1.5.4.3.3.3 | **Impermeabilização das Fachadas** |  | 52d | 2028-06-24 | 2028-08-15 |  | 5d |  |  |
| 72 | 1.5.4.3.3.3.1 | Demolições e Lavagem |  | 12d | 2028-06-24 | 2028-07-06 | 66 | 5d | 0d |  |
| 73 | 1.5.4.3.3.3.2 | Aplicação de Novo Revestimento Externo |  | 40d | 2028-07-06 | 2028-08-15 | 72 | 5d |  |  |
| 74 | 1.5.4.3.3.4 | Recuperação das pinturas internas |  | 45d | 2028-08-20 | 2028-10-04 | 73, 70 | 0d |  | Aumento de 15 dias |
| 75 | 1.5.4.3.3.5 | Recebimento Etapa | milestone | 0d | 2028-10-09 | 2028-10-09 | 74FS+5d, 70 | 0d |  |  |
| 76 | 1.5.4.3.4 | **Bloco 4** |  | 107d | 2028-10-09 | 2029-01-24 |  | 0d |  |  |
| 77 | 1.5.4.3.4.1 | Ordem de Serviço Etapa | milestone | 0d | 2028-10-09 | 2028-10-09 | 75 | 0d |  |  |
| 78 | 1.5.4.3.4.2 | **Impermeabilização da Cobertura** |  | 57d | 2028-10-09 | 2028-12-05 |  | 0d |  |  |
| 79 | 1.5.4.3.4.2.1 | Demolições e Retiradas |  | 11d | 2028-10-09 | 2028-10-20 | 77 | 0d |  |  |
| 80 | 1.5.4.3.4.2.2 | Serviços preparatórios |  | 11d | 2028-10-15 | 2028-10-26 | 79FS-5d | 0d |  |  |
| 81 | 1.5.4.3.4.2.3 | Aplicação de Sistema de Impermeabilização |  | 40d | 2028-10-26 | 2028-12-05 | 80 | 0d |  |  |
| 82 | 1.5.4.3.4.3 | **Impermeabilização das Fachadas** |  | 52d | 2028-10-09 | 2028-11-30 |  | 5d |  |  |
| 83 | 1.5.4.3.4.3.1 | Demolições e Lavagem |  | 12d | 2028-10-09 | 2028-10-21 | 77 | 5d | 0d |  |
| 84 | 1.5.4.3.4.3.2 | Aplicação de Novo Revestimento Externo |  | 40d | 2028-10-21 | 2028-11-30 | 83 | 5d |  |  |
| 85 | 1.5.4.3.4.4 | Recuperação das pinturas internas |  | 45d | 2028-12-05 | 2029-01-19 | 81, 84 | 0d |  | Aumento de 15 dias |
| 86 | 1.5.4.3.4.5 | Recebimento Etapa | milestone | 0d | 2029-01-24 | 2029-01-24 | 85FS+5d, 81 | 0d |  |  |

| ID | WBS | Task | Type | Duration | Start | Finish | Predecessors | Total slack | Free slack | Text1 |
| --- | --- | --- | --- | --- | --- | --- | --- | --- | --- | --- |
| 87 | 1.5.4.3.5 | **Bloco 5** |  | 107d | 2029-01-24 | 2029-05-11 |  | 0d |  |  |
| 88 | 1.5.4.3.5.1 | Ordem de Serviço Etapa | milestone | 0d | 2029-01-24 | 2029-01-24 | 86 | 0d |  |  |
| 89 | 1.5.4.3.5.2 | **Impermeabilização da Cobertura** |  | 57d | 2029-01-24 | 2029-03-22 |  | 0d |  |  |
| 90 | 1.5.4.3.5.2.1 | Demolições e Retiradas |  | 11d | 2029-01-24 | 2029-02-04 | 88 | 0d |  |  |
| 91 | 1.5.4.3.5.2.2 | Serviços preparatórios |  | 11d | 2029-01-30 | 2029-02-10 | 90FS-5d | 0d |  |  |
| 92 | 1.5.4.3.5.2.3 | Aplicação de Sistema de Impermeabilização |  | 40d | 2029-02-10 | 2029-03-22 | 91 | 0d |  |  |
| 93 | 1.5.4.3.5.3 | **Impermeabilização das Fachadas** |  | 52d | 2029-01-24 | 2029-03-17 |  | 5d |  |  |
| 94 | 1.5.4.3.5.3.1 | Demolições e Lavagem |  | 12d | 2029-01-24 | 2029-02-05 | 88 | 5d | 0d |  |
| 95 | 1.5.4.3.5.3.2 | Aplicação de Novo Revestimento Externo |  | 40d | 2029-02-05 | 2029-03-17 | 94 | 5d |  |  |
| 96 | 1.5.4.3.5.4 | Recuperação das pinturas internas |  | 45d | 2029-03-22 | 2029-05-06 | 95, 92 | 0d |  | Aumento de 15 dias |
| 97 | 1.5.4.3.5.5 | Recebimento Etapa | milestone | 0d | 2029-05-11 | 2029-05-11 | 96FS+5d, 92 | 0d |  |  |
| 98 | 1.5.4.3.6 | **Bloco 6** |  | 127d | 2029-05-11 | 2029-09-15 |  | 0d |  |  |
| 99 | 1.5.4.3.6.1 | Ordem de Serviço Etapa | milestone | 0d | 2029-05-11 | 2029-05-11 | 97 | 0d |  |  |
| 100 | 1.5.4.3.6.2 | **Impermeabilização da Cobertura** |  | 47d | 2029-05-11 | 2029-06-27 |  | 20d |  |  |
| 101 | 1.5.4.3.6.2.1 | Demolições e Retiradas |  | 11d | 2029-05-11 | 2029-05-22 | 99 | 20d | 0d |  |
| 102 | 1.5.4.3.6.2.2 | Serviços preparatórios |  | 11d | 2029-05-17 | 2029-05-28 | 101FS-5d | 20d | 0d |  |
| 103 | 1.5.4.3.6.2.3 | Aplicação de Sistema de Impermeabilização |  | 30d | 2029-05-28 | 2029-06-27 | 102 | 20d |  |  |
| 104 | 1.5.4.3.6.3 | **Impermeabilização das Fachadas** |  | 67d | 2029-05-11 | 2029-07-17 |  | 0d |  |  |
| 105 | 1.5.4.3.6.3.1 | Demolições e Lavagem |  | 12d | 2029-05-11 | 2029-05-23 | 99 | 0d |  |  |
| 106 | 1.5.4.3.6.3.2 | Aplicação de Novo Revestimento Externo |  | 55d | 2029-05-23 | 2029-07-17 | 105 | 0d |  |  |
| 107 | 1.5.4.3.6.4 | Recuperação das pinturas internas |  | 55d | 2029-07-17 | 2029-09-10 | 103, 106 | 0d |  | Aumento de 15 dias |
| 108 | 1.5.4.3.6.5 | Recebimento Etapa | milestone | 0d | 2029-09-15 | 2029-09-15 | 107FS+5d, 103 | 0d |  |  |
| 109 | 1.5.4.4 | Instalações Elétricas |  | 30d | 2029-09-15 | 2029-10-15 | 108, 42 | 10d |  |  |
| 110 | 1.5.4.5 | Instalações Mecânicas |  | 30d | 2029-09-15 | 2029-10-15 | 108, 42 | 10d |  |  |
| 111 | 1.5.4.6 | Aplicação de Revestimentos e Serviços Finais de Paisagismo na Cobertura |  | 40d | 2029-09-15 | 2029-10-25 | 108, 42 | 0d |  |  |
| 112 | 1.5.4.7 | Revestimentos da Cobertura |  | 40d | 2029-09-15 | 2029-10-25 | 108, 42 | 0d |  |  |
| 113 | 1.5.4.8 | Desmobilização e Limpeza Final |  | 10d | 2029-10-25 | 2029-11-04 | 111, 38FF, 109, 110, 112, 41FF | 0d |  |  |
| 114 | 1.6 | Final dos Serviços Operacionais | milestone | 0d | 2029-11-04 | 2029-11-04 | 113 | 0d |  |  |
| 115 | 1.7 | Recebimento Provisório da Obra |  | 15d | 2029-11-19 | 2029-12-04 | 114FS+15d | 0d |  |  |
| 116 | 1.8 | Recebimento Definitivo da Obra | milestone | 0d | 2030-03-04 | 2030-03-04 | 115FS+90d | 0d |  |  |
| 117 | 1.9 | Encerramento do Contrato | milestone | 0d | 2030-06-02 | 2030-06-02 | 116FS+90d | 0d |  |  |
